# UNIJOS LECTURE HALL(AMENDED)

Schedule from MS Project, 2020-06-24 to 2020-11-24.

## Calendars

- Standard: Mon-Sat 08:00-12:00, 13:00-17:00; Sun off.

## Schedule

| ID | WBS | Task | Duration | Start | Finish | Predecessors | Total slack | Free slack |
| --- | --- | --- | --- | --- | --- | --- | --- | --- |
| 1 | 1 | **SITE WORKS(INCLUSIVE OF PROCUREMENT OF MATERIAL)** | 107d | 2020-06-24 | 2020-10-26 |  | 0d |  |
| 2 | 1.1 | Completion of Frames structures (slabs, staircases, beams and roof beams) | 25d | 2020-06-24 | 2020-07-22 |  | 12d | 0d |
| 3 | 1.2 | Completion of Internal and External Walls | 15d | 2020-07-11 | 2020-07-28 | 2FS-10d | 12d | 0d |
| 4 | 1.3 | Roof and Roof Covering( Metal profile/flat sheet cladding/covering/siding) | 12d | 2020-07-29 | 2020-08-11 | 2FS-10d, 3 | 12d | 0d |
| 5 | 1.4 | Doors and Iron Mongery | 12d | 2020-07-17 | 2020-07-30 | 3FS-10d | 75d |  |
| 6 | 1.5 | Placement of Windows | 12d | 2020-08-12 | 2020-08-25 | 4 | 53d |  |
| 7 | 1.6 | Electrical Works | 17d | 2020-08-12 | 2020-08-31 | 4 | 12d | 0d |
| 8 | 1.7 | Plumbing Works | 13d | 2020-08-12 | 2020-08-26 | 4 | 16d | 4d |
| 9 | 1.8 | Floor, Wall and Ceiling Finishings | 16d | 2020-08-26 | 2020-09-12 | 7FS-5d, 8FS-5d | 12d | 0d |
| 10 | 1.9 | Mechanical (inclusive of Air-Conditioning/Ventillation Installations) | 25d | 2020-09-14 | 2020-10-12 | 9 | 12d |  |
| 11 | 1.10 | Painting and Decorating | 12d | 2020-09-18 | 2020-10-01 | 9FS+4d | 21d |  |
| 12 | 1.11 | Other Ancillary Works | 107d | 2020-06-24 | 2020-10-26 |  | 0d |  |
| 13 | 2 | **EXTERNAL WORKS** | 60d | 2020-08-29 | 2020-11-06 | 1FS-50d | 0d |  |
| 14 | 2.1 | External Lighting | 20d | 2020-08-29 | 2020-09-21 |  | 40d |  |
| 15 | 2.2 | External Water Supply | 10d | 2020-08-29 | 2020-09-09 |  | 4d | 0d |
| 16 | 2.3 | Waste Drainages | 10d | 2020-09-04 | 2020-09-15 | 15FS-5d | 4d | 0d |
| 17 | 2.4 | Driverways/Walkaways/Parkings | 15d | 2020-09-17 | 2020-10-03 | 15FS+6d, 16FS+1d | 4d | 0d |
| 18 | 2.5 | Soft Landscapping | 15d | 2020-09-23 | 2020-10-09 | 17FS-10d | 4d | 0d |
| 19 | 2.6 | Drainages | 25d | 2020-10-05 | 2020-11-02 | 16FS-5d, 17FS-5d, 18FS-5d | 4d |  |
| 20 | 2.7 | Other External Ancillary Works | 60d | 2020-08-29 | 2020-11-06 |  | 0d |  |
| 21 | 3 | **SITE CLEANUP AND DEMOBILISATION** | 5d | 2020-11-07 | 2020-11-12 | 13 | 0d |  |
| 22 | 3.1 | Clear building site of construction/demolition waste | 5d | 2020-11-07 | 2020-11-12 |  | 0d |  |
| 23 | 3.2 | Demobilse Personnel and equipment from site | 5d | 2020-11-07 | 2020-11-12 |  | 0d |  |
| 24 | 4 | **PROJECT COMMISSIONING** | 10d | 2020-11-13 | 2020-11-24 | 13FS-2d, 21 | 0d |  |
| 25 | 4.1 | Final Inspection/Hand-over of project site to Client | 9d | 2020-11-13 | 2020-11-23 |  | 0d |  |
| 26 | 4.2 | Commissioning of project | 1d | 2020-11-24 | 2020-11-24 | 25 | 0d |  |
